# You are beautiful w10

Schedule from MS Project, 2013-09-10 to 2014-02-27, costs in €, A marks actual dates.
Project CPM
Rode Kruis Studentendesk Nijmegen

## Calendars

- You are Beautiful: Mon-Tue off; Wed-Thu 15:00-17:00; Fri-Sun off. Exceptions (off unless hours are given): 2013-10-14 to 2013-10-18 (Herfstvakantie), 2013-12-23 to 2014-01-03 (Kerstvakantie).
- 24 uur: Mon-Sun 00:00-24:00.

## Resources

| Resource | Group | Cost per use |
| --- | --- | --- |
| Nicole van Ham | Student |  |
| Cédric Cortenraad | Student |  |
| Roosmarijn Doedens | Student |  |
| Corine Somers | Student |  |
| Joyce Bruil | Docent |  |
| Kimberly van der Laan | Opdrachtgever |  |
| Verstandelijk beperkten | Modellen |  |
| Vrijwilligers | Vrijwilliger |  |
| Dansschool Vermeulen |  | 150 |
| Vermeulen |  |  |
| Kapper |  |  |
| visagist |  |  |
| Benodigheden kapper/visagist |  |  |
| Fotograaf |  |  |
| Presentator Joost Brauwer |  |  |
| Broodjes smeerders |  |  |
| Eten/ drinken/bekers/borden |  |  |
| Kleding |  |  |
| Rode Loper |  |  |
| Versiering |  |  |
| Muziek |  |  |
| Goodiebags |  |  |
| Koffie |  |  |

## Schedule

| ID | WBS | Task | Duration | Start | Finish | Predecessors | Complete | Baseline start | Baseline finish | Baseline duration | Baseline 1 start | Baseline 1 finish | Constraint | Deadline | Calendar | Resources | Work | Actual work |
| --- | --- | --- | --- | --- | --- | --- | --- | --- | --- | --- | --- | --- | --- | --- | --- | --- | --- | --- |
| 1 | 1 | **Voorbereidingsfase** | 1.03d | 2013-09-10 16:00 A | 2013-09-25 15:15 A |  | 100% | 2013-09-10 16:00 | 2013-09-25 15:15 | 1.03d | 2013-09-10 16:00 | 2013-09-25 15:15 |  |  |  |  | 58h | 58h |
| 2 | 1.1 | Voorbereidend gesprek met opdrachtgever | 2h | 2013-09-10 16:00 A | 2013-09-10 18:00 A |  | 100% | 2013-09-10 16:00 | 2013-09-10 18:00 | 2h | 2013-09-10 16:00 | 2013-09-10 18:00 | must start on 2013-09-10 16:00 |  | 24 uur | Cédric Cortenraad; Corine Somers; Nicole van Ham; Roosmarijn Doedens; Kimberly van der Laan | 10h | 10h |
| 3 | 1.2 | Project bestand aanmaken | 2h | 2013-09-11 15:00 A | 2013-09-11 17:00 A | 2 | 100% | 2013-09-11 15:00 | 2013-09-11 17:00 | 2h | 2013-09-11 15:00 | 2013-09-11 17:00 |  |  |  | Cédric Cortenraad; Corine Somers; Nicole van Ham; Roosmarijn Doedens | 16h | 16h |
| 4 | 1.3 | **Opdracht 1 Resultaten beschrijven** | 0.34d | 2013-09-12 15:00 A | 2013-09-18 15:45 A | 3 | 100% | 2013-09-12 15:00 | 2013-09-18 15:45 | 0.34d | 2013-09-12 15:00 | 2013-09-18 15:45 |  |  |  |  | 11h | 11h |
| 5 | 1.3.1 | Voorbereiden projectresultaat | 1.75h | 2013-09-12 15:00 A | 2013-09-12 16:45 A |  | 100% | 2013-09-12 15:00 | 2013-09-12 16:45 | 1.75h | 2013-09-12 15:00 | 2013-09-12 16:45 |  |  |  | Cédric Cortenraad | 1.75h | 1.75h |
| 6 | 1.3.2 | Voorbereiden organisatieresultaat | 1.75h | 2013-09-12 15:00 A | 2013-09-12 16:45 A |  | 100% | 2013-09-12 15:00 | 2013-09-12 16:45 | 1.75h | 2013-09-12 15:00 | 2013-09-12 16:45 |  |  |  | Corine Somers | 1.75h | 1.75h |
| 7 | 1.3.3 | Voorbereiden omgevingsresultaat | 1.75h | 2013-09-12 15:00 A | 2013-09-12 16:45 A |  | 100% | 2013-09-12 15:00 | 2013-09-12 16:45 | 1.75h | 2013-09-12 15:00 | 2013-09-12 16:45 |  |  |  | Nicole van Ham | 1.75h | 1.75h |
| 8 | 1.3.4 | Voorbereiden bedrijfsresultaat | 1.75h | 2013-09-12 15:00 A | 2013-09-12 16:45 A |  | 100% | 2013-09-12 15:00 | 2013-09-12 16:45 | 1.75h | 2013-09-12 15:00 | 2013-09-12 16:45 |  |  |  | Roosmarijn Doedens | 1.75h | 1.75h |
| 9 | 1.3.5 | Bespreken projectresultaat | 0.25h | 2013-09-12 16:45 A | 2013-09-12 17:00 A | 5 | 100% | 2013-09-12 16:45 | 2013-09-12 17:00 | 0.25h | 2013-09-12 16:45 | 2013-09-12 17:00 |  |  |  | Cédric Cortenraad; Corine Somers; Nicole van Ham; Roosmarijn Doedens | 1h | 1h |
| 10 | 1.3.6 | Bespreken organisatieresultaat | 0.25h | 2013-09-18 15:00 A | 2013-09-18 15:15 A | 6, 9 | 100% | 2013-09-18 15:00 | 2013-09-18 15:15 | 0.25h | 2013-09-18 15:00 | 2013-09-18 15:15 |  |  |  | Cédric Cortenraad; Corine Somers; Nicole van Ham; Roosmarijn Doedens | 1h | 1h |
| 11 | 1.3.7 | Bespreken omgevingsresultaat | 0.25h | 2013-09-18 15:15 A | 2013-09-18 15:30 A | 7, 10 | 100% | 2013-09-18 15:15 | 2013-09-18 15:30 | 0.25h | 2013-09-18 15:15 | 2013-09-18 15:30 |  |  |  | Cédric Cortenraad; Corine Somers; Nicole van Ham; Roosmarijn Doedens | 1h | 1h |
| 12 | 1.3.8 | Bespreken bedrijfsresultaat | 0.25h | 2013-09-18 15:30 A | 2013-09-18 15:45 A | 8, 11 | 100% | 2013-09-18 15:30 | 2013-09-18 15:45 | 0.25h | 2013-09-18 15:30 | 2013-09-18 15:45 |  |  |  | Cédric Cortenraad; Corine Somers; Nicole van Ham; Roosmarijn Doedens | 1h | 1h |
| 13 | 1.4 | Opdracht 2 structurele inbedding | 0.5h | 2013-09-18 15:45 A | 2013-09-18 16:15 A | 4 | 100% | 2013-09-18 15:45 | 2013-09-18 16:15 | 0.5h | 2013-09-18 15:45 | 2013-09-18 16:15 |  |  |  | Cédric Cortenraad; Corine Somers; Nicole van Ham; Roosmarijn Doedens | 2h | 2h |
| 14 | 1.5 | **Opdracht 3** | 0d | 2013-09-18 16:15 A | 2013-09-18 16:16 A | 13 | 100% | 2013-09-18 16:15 | 2013-09-18 16:16 | 0d | 2013-09-18 16:15 | 2013-09-18 16:16 |  |  |  |  | 8h | 8h |
| 15 | 1.5.1 | Belanghebbende in kaart brengen | 0.02h | 2013-09-18 16:15 A | 2013-09-18 16:16 A |  | 100% | 2013-09-18 16:15 | 2013-09-18 16:16 | 0.02h | 2013-09-18 16:15 | 2013-09-18 16:16 |  |  |  | Cédric Cortenraad; Corine Somers | 3h | 3h |
| 16 | 1.5.2 | Belang en verantwoordelijkheid in kaart brengen | 0.02h | 2013-09-18 16:15 A | 2013-09-18 16:16 A |  | 100% | 2013-09-18 16:15 | 2013-09-18 16:16 | 0.02h | 2013-09-18 16:15 | 2013-09-18 16:16 |  |  |  | Nicole van Ham; Roosmarijn Doedens | 5h | 5h |
| 17 | 1.6 | **Opdracht 4** | 0.09d | 2013-09-18 16:16 A | 2013-09-19 15:00 A | 14 | 100% | 2013-09-18 16:16 | 2013-09-19 15:00 | 0.09d | 2013-09-18 16:16 | 2013-09-19 15:00 |  |  |  |  | 4h | 4h |
| 18 | 1.6.1 | krachtenveldanalyse | 0.73h | 2013-09-18 16:16 A | 2013-09-19 15:00 A |  | 100% | 2013-09-18 16:16 | 2013-09-19 15:00 | 0.73h | 2013-09-18 16:16 | 2013-09-19 15:00 |  |  |  | Cédric Cortenraad | 1h | 1h |
| 19 | 1.6.2 | relevantieanalyse | 0.73h | 2013-09-18 16:16 A | 2013-09-19 15:00 A |  | 100% | 2013-09-18 16:16 | 2013-09-19 15:00 | 0.73h | 2013-09-18 16:16 | 2013-09-19 15:00 |  |  |  | Corine Somers | 1h | 1h |
| 20 | 1.6.3 | houdingsanalyse | 0.73h | 2013-09-18 16:16 A | 2013-09-19 15:00 A |  | 100% | 2013-09-18 16:16 | 2013-09-19 15:00 | 0.73h | 2013-09-18 16:16 | 2013-09-19 15:00 |  |  |  | Nicole van Ham | 1h | 1h |
| 21 | 1.6.4 | Invloed analyses | 0.73h | 2013-09-18 16:16 A | 2013-09-19 15:00 A |  | 100% | 2013-09-18 16:16 | 2013-09-19 15:00 | 0.73h | 2013-09-18 16:16 | 2013-09-19 15:00 |  |  |  | Roosmarijn Doedens | 1h | 1h |
| 22 | 1.7 | **Samenvatting resultaten tot nu toe** | 0.16d | 2013-09-19 15:00 A | 2013-09-19 16:15 A |  | 100% | 2013-09-19 15:00 | 2013-09-19 16:15 | 0.16d | 2013-09-19 15:00 | 2013-09-19 16:15 |  |  |  |  | 2h | 2h |
| 23 | 1.7.1 | Schrijven samenvatting | 1h | 2013-09-19 15:00 A | 2013-09-19 16:00 A | 14 | 100% | 2013-09-19 15:00 | 2013-09-19 16:00 | 1h | 2013-09-19 15:00 | 2013-09-19 16:00 |  |  |  | Corine Somers | 1h | 1h |
| 24 | 1.7.2 | Kritisch bekijken samenvatting | 0.25h | 2013-09-19 16:00 A | 2013-09-19 16:15 A | 17, 23 | 100% | 2013-09-19 16:00 | 2013-09-19 16:15 | 0.25h | 2013-09-19 16:00 | 2013-09-19 16:15 |  |  |  | Cédric Cortenraad; Corine Somers; Nicole van Ham; Roosmarijn Doedens | 1h | 1h |
| 25 | 1.8 | Voortgangsgesprek met de opdrachtgever | 1h | 2013-09-24 10:00 A | 2013-09-24 11:00 A |  | 100% | 2013-09-24 10:00 | 2013-09-24 11:00 | 1h | 2013-09-24 10:00 | 2013-09-24 11:00 | must start on 2013-09-24 10:00 |  | 24 uur | Cédric Cortenraad; Corine Somers; Nicole van Ham; Roosmarijn Doedens; Kimberly van der Laan | 5h | 5h |
| 26 | 1.9 | aanvragen project | 0.25h | 2013-09-25 15:00 A | 2013-09-25 15:15 A | 25 | 100% | 2013-09-25 15:00 | 2013-09-25 15:15 | 0.25h | 2013-09-25 15:00 | 2013-09-25 15:15 |  | 2013-09-26 17:00 |  |  |  |  |

| ID | WBS | Task | Duration | Start | Finish | Predecessors | Complete | Baseline start | Baseline finish | Baseline duration | Baseline 1 start | Baseline 1 finish | Constraint | Deadline | Resources | Work | Actual work |
| --- | --- | --- | --- | --- | --- | --- | --- | --- | --- | --- | --- | --- | --- | --- | --- | --- | --- |
| 27 | 2 | **Definitiefase** | 2.47d | 2013-09-25 15:15 A | 2013-10-31 17:00 A | 1 | 100% | 2013-09-25 15:15 | 2013-10-31 17:00 | 2.47d | 2013-09-25 15:15 | 2013-10-10 17:00 |  |  |  | 72.25h | 72.25h |
| 28 | 2.1 | Planning definitiefase | 0.5h | 2013-09-25 15:15 A | 2013-09-25 15:45 A |  | 100% | 2013-09-25 15:15 | 2013-09-25 15:45 | 0.5h | 2013-09-25 15:15 | 2013-09-25 15:45 |  |  | Cédric Cortenraad; Corine Somers; Nicole van Ham; Roosmarijn Doedens | 0.5h | 0.5h |
| 29 | 2.2 | **Opdracht 5** | 0.31d | 2013-09-25 15:45 A | 2013-09-26 16:15 A | 28 | 100% | 2013-09-25 15:45 | 2013-09-26 16:15 | 0.31d | 2013-09-25 15:45 | 2013-09-26 16:15 |  |  |  | 9h | 9h |
| 30 | 2.2.1 | Alternatief 1 | 0.5h | 2013-09-25 15:45 A | 2013-09-25 16:15 A |  | 100% | 2013-09-25 15:45 | 2013-09-25 16:15 | 0.5h | 2013-09-25 15:45 | 2013-09-25 16:15 |  |  | Cédric Cortenraad; Corine Somers; Nicole van Ham; Roosmarijn Doedens | 2h | 2h |
| 31 | 2.2.2 | Alternatief 2 | 0.5h | 2013-09-25 16:15 A | 2013-09-25 16:45 A | 30 | 100% | 2013-09-25 16:15 | 2013-09-25 16:45 | 0.5h | 2013-09-25 16:15 | 2013-09-25 16:45 |  |  | Cédric Cortenraad; Corine Somers; Nicole van Ham; Roosmarijn Doedens | 2h | 2h |
| 32 | 2.2.3 | Alternatief 3 | 0.5h | 2013-09-25 16:45 A | 2013-09-26 15:15 A | 31 | 100% | 2013-09-25 16:45 | 2013-09-26 15:15 | 0.5h | 2013-09-25 16:45 | 2013-09-26 15:15 |  |  | Cédric Cortenraad; Corine Somers; Nicole van Ham; Roosmarijn Doedens | 2h | 2h |
| 33 | 2.2.4 | Uitwerking alternatief 1 | 1h | 2013-09-26 15:15 A | 2013-09-26 16:15 A | 32 | 100% | 2013-09-26 15:15 | 2013-09-26 16:15 | 1h | 2013-09-26 15:15 | 2013-09-26 16:15 |  |  | Cédric Cortenraad | 1h | 1h |
| 34 | 2.2.5 | Uitwerking alternatief 2 | 1h | 2013-09-26 15:15 A | 2013-09-26 16:15 A | 32 | 100% | 2013-09-26 15:15 | 2013-09-26 16:15 | 1h | 2013-09-26 15:15 | 2013-09-26 16:15 |  |  | Nicole van Ham | 1h | 1h |
| 35 | 2.2.6 | Uitwerking alternatief 3 | 1h | 2013-09-26 15:15 A | 2013-09-26 16:15 A | 32 | 100% | 2013-09-26 15:15 | 2013-09-26 16:15 | 1h | 2013-09-26 15:15 | 2013-09-26 16:15 |  |  | Roosmarijn Doedens | 1h | 1h |
| 36 | 2.3 | **Opdracht 6** | 0.09d | 2013-09-26 16:15 A | 2013-09-26 17:00 A | 29 | 100% | 2013-09-26 16:15 | 2013-09-26 17:00 | 0.09d | 2013-09-26 16:15 | 2013-09-26 17:00 |  |  |  | 0.75h | 0.75h |
| 37 | 2.3.1 | Projectplan stap 1 | 0.75h | 2013-09-26 16:15 A | 2013-09-26 17:00 A |  | 100% | 2013-09-26 16:15 | 2013-09-26 17:00 | 0.75h | 2013-09-26 16:15 | 2013-09-26 17:00 |  |  | Corine Somers | 0.75h | 0.75h |
| 38 | 2.4 | **Opdracht 7** | 1.12d | 2013-10-02 15:00 A | 2013-10-23 16:00 A | 36 | 100% | 2013-10-02 15:00 | 2013-10-23 16:00 | 1.12d | 2013-10-02 15:00 | 2013-10-03 17:00 | start no earlier than 2013-09-30 08:00 |  |  | 37h | 37h |
| 39 | 2.4.1 | WBS maken | 4h | 2013-10-02 15:00 A | 2013-10-03 17:00 A |  | 100% | 2013-10-02 15:00 | 2013-10-03 17:00 | 4h | 2013-10-02 15:00 | 2013-10-02 17:00 |  |  | Cédric Cortenraad; Corine Somers; Nicole van Ham; Roosmarijn Doedens | 16h | 16h |
| 40 | 2.4.2 | Producten project | 1h | 2013-10-09 16:00 A | 2013-10-09 17:00 A | 39, 42 | 100% | 2013-10-09 16:00 | 2013-10-09 17:00 | 1h | 2013-10-03 15:00 | 2013-10-03 15:30 |  |  | Cédric Cortenraad; Corine Somers; Nicole van Ham; Roosmarijn Doedens | 4h | 4h |
| 41 | 2.4.3 | PBS maken | 3h | 2013-10-10 15:00 A | 2013-10-23 16:00 A | 40 | 100% | 2013-10-10 15:00 | 2013-10-23 16:00 | 3h | 2013-10-03 15:30 | 2013-10-03 17:00 |  |  | Cédric Cortenraad; Corine Somers; Nicole van Ham; Roosmarijn Doedens | 12h | 12h |
| 42 | 2.4.4 | Afspraak 1 Joyce | 1h | 2013-10-09 15:00 A | 2013-10-09 16:00 A |  | 100% | 2013-10-09 15:00 | 2013-10-09 16:00 | 1h |  |  | must start on 2013-10-09 15:00 |  | Cédric Cortenraad; Corine Somers; Joyce Bruil; Nicole van Ham; Roosmarijn Doedens | 5h | 5h |
| 43 | 2.5 | **opdracht 8** | 0.5d | 2013-10-23 16:00 A | 2013-10-30 16:00 A | 38 | 100% | 2013-10-23 16:00 | 2013-10-30 16:00 | 0.5d | 2013-10-09 15:00 | 2013-10-10 17:00 |  |  |  | 16h | 16h |
| 44 | 2.5.1 | Inventarisatie risico's | 2h | 2013-10-23 16:00 A | 2013-10-24 16:00 A |  | 100% | 2013-10-23 16:00 | 2013-10-24 16:00 | 2h | 2013-10-09 15:00 | 2013-10-09 17:00 |  |  | Cédric Cortenraad; Corine Somers; Nicole van Ham; Roosmarijn Doedens | 8h | 8h |
| 45 | 2.5.2 | Inschatting risico's | 1h | 2013-10-24 16:00 A | 2013-10-24 17:00 A | 44 | 100% | 2013-10-24 16:00 | 2013-10-24 17:00 | 1h | 2013-10-10 15:00 | 2013-10-10 16:00 |  |  | Cédric Cortenraad; Corine Somers; Nicole van Ham; Roosmarijn Doedens | 4h | 4h |
| 46 | 2.5.3 | Tegen maatregelen bedenken | 1h | 2013-10-30 15:00 A | 2013-10-30 16:00 A | 45 | 100% | 2013-10-30 15:00 | 2013-10-30 16:00 | 1h | 2013-10-10 16:00 | 2013-10-10 17:00 |  |  | Cédric Cortenraad; Corine Somers; Nicole van Ham; Roosmarijn Doedens | 4h | 4h |
| 47 | 2.6 | **Projectplan** | 0.25d | 2013-10-30 16:00 A | 2013-10-31 16:00 A | 43 | 100% | 2013-10-30 16:00 | 2013-10-31 16:00 | 0.25d | 2013-09-25 15:15 | 2013-09-25 16:15 |  | 2013-10-31 17:00 |  | 5h | 5h |
| 48 | 2.6.1 | Concept projectplan | 1h | 2013-10-30 16:00 A | 2013-10-30 17:00 A |  | 100% | 2013-10-30 16:00 | 2013-10-30 17:00 | 1h |  |  |  |  | Corine Somers | 1h | 1h |
| 49 | 2.6.2 | Eind versie Projectplan | 1h | 2013-10-31 15:00 A | 2013-10-31 16:00 A | 48 | 100% | 2013-10-31 15:00 | 2013-10-31 16:00 | 1h |  |  |  |  | Cédric Cortenraad; Corine Somers; Nicole van Ham; Roosmarijn Doedens | 4h | 4h |
| 50 | 2.7 | Evaluatie definitiefase | 1h | 2013-10-31 16:00 A | 2013-10-31 17:00 A | 47 | 100% | 2013-10-31 16:00 | 2013-10-31 17:00 | 1h |  |  |  |  | Cédric Cortenraad; Corine Somers; Nicole van Ham; Roosmarijn Doedens | 4h | 4h |

| ID | WBS | Task | Duration | Start | Finish | Predecessors | Complete | Baseline start | Baseline finish | Baseline duration | Baseline 1 start | Baseline 1 finish | Constraint | Deadline | Resources | Work | Actual work | Cost | Actual cost |
| --- | --- | --- | --- | --- | --- | --- | --- | --- | --- | --- | --- | --- | --- | --- | --- | --- | --- | --- | --- |
| 51 | 3 | **Uitvoeringsfase** | 56.62d? | 2013-11-11 09:00 A | 2014-02-10 12:00 A |  | 100% | 2013-11-11 09:00 | 2014-02-10 12:00 | 56.62d? | 2013-09-11 15:00 | 2013-09-19 17:00 | start no earlier than 2013-11-11 08:00 |  |  | 611.08h | 611.08h | 585 | 230 |
| 52 | 3.1 | **Werven/voorbereiden/regelen** | 45d? | 2013-11-11 09:00 A | 2014-01-24 17:00 A |  | 100% | 2013-11-11 09:00 | 2014-01-24 17:00 | 45d? |  |  |  | 2014-01-27 17:00 |  | 100h | 100h |  |  |
| 53 | 3.1.1 | **Rode kruis** | 45d | 2013-11-11 09:00 A | 2014-01-24 17:00 A |  | 100% | 2013-11-11 09:00 | 2014-01-24 17:00 | 9w |  |  |  |  |  | 11h | 11h |  |  |
| 54 | 3.1.1.1 | Overleg | 9w | 2013-11-11 09:00 A | 2014-01-24 17:00 A |  | 100% |  |  |  |  |  |  |  | Cédric Cortenraad; Corine Somers; Nicole van Ham; Roosmarijn Doedens | 8h | 8h |  |  |
| 55 | 3.1.1.2 | mailen | 9w | 2013-11-11 09:00 A | 2014-01-24 17:00 A |  | 100% |  |  |  |  |  |  |  | Nicole van Ham | 2h | 2h |  |  |
| 56 | 3.1.1.3 | bellen | 9w | 2013-11-11 09:00 A | 2014-01-24 17:00 A |  | 100% |  |  |  |  |  |  |  | Nicole van Ham | 1h | 1h |  |  |
| 57 | 3.1.2 | **Verstandelijk beperkten** | 30d | 2013-11-11 09:00 A | 2013-12-20 17:00 A |  | 100% | 2013-11-11 09:00 | 2013-12-20 17:00 | 6w |  |  |  |  |  | 8h | 8h |  |  |
| 58 | 3.1.2.1 | Pluryn | 6w | 2013-11-11 09:00 A | 2013-12-20 17:00 A |  | 100% |  |  |  |  |  |  |  | Cédric Cortenraad; Roosmarijn Doedens | 4h | 4h |  |  |
| 59 | 3.1.2.2 | Overige | 6w | 2013-11-11 09:00 A | 2013-12-20 17:00 A |  | 100% |  |  |  |  |  |  |  | Corine Somers; Nicole van Ham | 4h | 4h |  |  |
| 60 | 3.1.3 | **Vrijwilligers** | 30d | 2013-11-11 09:00 A | 2013-12-20 17:00 A |  | 100% | 2013-11-11 09:00 | 2014-01-24 17:00 | 9w |  |  |  |  |  | 3h | 3h |  |  |
| 61 | 3.1.3.1 | Pluryn | 6w | 2013-11-11 09:00 A | 2013-12-20 17:00 A |  | 100% |  |  |  |  |  |  |  | Cédric Cortenraad; Roosmarijn Doedens | 2h | 2h |  |  |
| 62 | 3.1.3.2 | Overige | 6w | 2013-11-11 09:00 A | 2013-12-20 17:00 A |  | 100% |  |  |  |  |  |  |  | Roosmarijn Doedens | 1h | 1h |  |  |
| 63 | 3.1.4 | **Sponsors** | 45d | 2013-11-11 09:00 A | 2014-01-24 17:00 A |  | 100% | 2013-11-11 09:00 | 2014-01-24 17:00 | 9w |  |  |  |  |  | 20h | 20h |  |  |
| 64 | 3.1.4.1 | Rabobank | 6w | 2013-11-11 09:00 A | 2013-12-20 17:00 A |  | 100% |  |  |  |  |  |  |  | Corine Somers; Roosmarijn Doedens | 3h | 3h |  |  |
| 65 | 3.1.4.2 | ABN AMRO | 6w | 2013-11-11 09:00 A | 2013-12-20 17:00 A |  | 100% |  |  |  |  |  |  |  | Corine Somers; Roosmarijn Doedens | 3h | 3h |  |  |
| 66 | 3.1.4.3 | HAN | 6w | 2013-11-11 09:00 A | 2013-12-20 17:00 A |  | 100% |  |  |  |  |  |  |  | Corine Somers; Roosmarijn Doedens | 2h | 2h |  |  |
| 67 | 3.1.4.4 | Overige | 9w | 2013-11-11 09:00 A | 2014-01-24 17:00 A |  | 100% |  |  |  |  |  |  |  | Corine Somers; Roosmarijn Doedens | 12h | 12h |  |  |
| 68 | 3.1.5 | Subsidie | 3w | 2013-11-11 09:00 A | 2013-11-29 17:00 A |  | 100% | 2013-11-11 09:00 | 2013-11-29 17:00 | 3w |  |  |  |  | Roosmarijn Doedens | 4h | 4h |  |  |
| 69 | 3.1.6 | **Locatie** | 30d | 2013-11-11 09:00 A | 2013-12-20 17:00 A |  | 100% | 2013-11-11 09:00 | 2013-12-20 17:00 | 6w |  |  |  |  |  | 6h | 6h |  |  |
| 70 | 3.1.6.1 | Kolpinghuis | 3w | 2013-11-11 09:00 A | 2013-11-29 17:00 A |  | 100% |  |  |  |  |  |  |  | Nicole van Ham | 2h | 2h |  |  |
| 71 | 3.1.6.2 | Dansschool vermeulen | 3w | 2013-12-02 09:00 A | 2013-12-20 17:00 A | 70 | 100% |  |  |  |  |  |  |  | Cédric Cortenraad; Roosmarijn Doedens | 4h | 4h |  |  |
| 72 | 3.1.7 | **Specialisten** | 45d? | 2013-11-11 09:00 A | 2014-01-24 17:00 A |  | 100% | 2013-11-11 09:00 | 2014-01-24 17:00 | 45d? |  |  |  |  |  | 28h | 28h |  |  |
| 73 | 3.1.7.1 | Presentator | 9w | 2013-11-11 09:00 A | 2014-01-24 17:00 A |  | 100% | 2013-11-11 09:00 | 2014-01-24 17:00 | 9w |  |  |  |  | Roosmarijn Doedens | 4h | 4h |  |  |
| 74 | 3.1.7.2 | Visagisten/kappers | 9w | 2013-11-11 09:00 A | 2014-01-24 17:00 A |  | 100% | 2013-11-11 09:00 | 2014-01-24 17:00 | 9w |  |  |  |  | Cédric Cortenraad | 4h | 4h |  |  |

| ID | WBS | Task | Type | Duration | Start | Finish | Predecessors | Complete | Actual finish | Baseline start | Baseline finish | Baseline duration | Constraint | Deadline | Resources | Work | Actual work | Cost | Actual cost |
| --- | --- | --- | --- | --- | --- | --- | --- | --- | --- | --- | --- | --- | --- | --- | --- | --- | --- | --- | --- |
| 75 | 3.1.7.3 | **Fotograaf** |  | 45d | 2013-11-11 09:00 A | 2014-01-24 17:00 A |  | 100% |  | 2013-11-11 09:00 | 2014-01-24 17:00 | 45d |  |  |  | 4h | 4h |  |  |
| 76 | 3.1.7.3.1 | Zoeken |  | 9w | 2013-11-11 09:00 A | 2014-01-24 17:00 A |  | 100% |  | 2013-11-11 09:00 | 2014-01-24 17:00 | 9w |  |  | Corine Somers | 2h | 2h |  |  |
| 77 | 3.1.7.3.2 | afspraken |  | 9w | 2013-11-11 09:00 A | 2014-01-24 17:00 A |  | 100% |  | 2013-11-11 09:00 | 2014-01-24 17:00 | 9w |  |  | Corine Somers | 2h | 2h |  |  |
| 78 | 3.1.7.4 | Pers |  | 9w | 2013-11-11 09:00 A | 2014-01-24 17:00 A |  | 100% |  | 2013-11-11 09:00 | 2014-01-24 17:00 | 9w |  |  | Cédric Cortenraad | 8h | 8h |  |  |
| 79 | 3.1.7.5 | **Catering** |  | 0d? | 2013-11-11 09:00 A | 2013-11-11 09:00 |  | 100% | 2014-01-24 17:00 | 2013-11-11 09:00 | 2013-11-11 09:00 | 0d? |  |  |  | 8h | 8h |  |  |
| 80 | 3.1.7.5.1 | Offertes aanvragen |  | 6w | 2013-11-11 09:00 A | 2013-12-20 17:00 A |  | 100% |  | 2013-11-11 09:00 | 2013-12-20 17:00 | 6w |  |  | Nicole van Ham | 2h | 2h |  |  |
| 81 | 3.1.7.5.2 | Offertes selecteren |  | 2w | 2014-01-06 09:00 A | 2014-01-17 17:00 A | 80 | 100% |  | 2014-01-06 09:00 | 2014-01-17 17:00 | 2w |  |  | Nicole van Ham | 2h | 2h |  |  |
| 82 | 3.1.7.5.3 | Contract cateraar |  | 1w | 2014-01-20 09:00 A | 2014-01-24 17:00 A | 81 | 100% |  | 2014-01-20 09:00 | 2014-01-24 17:00 | 1w |  |  | Nicole van Ham; Cédric Cortenraad | 4h | 4h |  |  |
| 83 | 3.1.8 | **Materialen** |  | 45d | 2013-11-11 09:00 A | 2014-01-24 17:00 A |  | 100% |  | 2013-11-11 09:00 | 2014-01-24 17:00 | 45d |  |  |  | 20h | 20h |  |  |
| 84 | 3.1.8.1 | Kleding |  | 6w | 2013-11-11 09:00 A | 2013-12-20 17:00 A |  | 100% |  | 2013-11-11 09:00 | 2013-12-20 17:00 | 6w |  |  | Cédric Cortenraad; Roosmarijn Doedens | 4h | 4h |  |  |
| 85 | 3.1.8.2 | Rode loper |  | 9w | 2013-11-11 09:00 A | 2014-01-24 17:00 A |  | 100% |  | 2013-11-11 09:00 | 2014-01-24 17:00 | 9w |  |  | Roosmarijn Doedens | 4h | 4h |  |  |
| 86 | 3.1.8.3 | Versiering |  | 3w | 2014-01-06 09:00 A | 2014-01-24 17:00 A |  | 100% |  | 2014-01-06 09:00 | 2014-01-24 17:00 | 3w | start no earlier than 2014-01-06 09:00 |  | Nicole van Ham | 2h | 2h |  |  |
| 87 | 3.1.8.4 | Muziek |  | 3w | 2014-01-06 09:00 A | 2014-01-24 17:00 A |  | 100% |  | 2014-01-06 09:00 | 2014-01-24 17:00 | 3w | start no earlier than 2014-01-06 09:00 |  | Roosmarijn Doedens | 2h | 2h |  |  |
| 88 | 3.1.8.5 | Goodiebag |  | 9w | 2013-11-11 09:00 A | 2014-01-24 17:00 A |  | 100% |  | 2013-11-11 09:00 | 2014-01-24 17:00 | 9w |  |  | Cédric Cortenraad; Corine Somers; Nicole van Ham; Roosmarijn Doedens | 8h | 8h |  |  |
| 89 | 3.2 | **Inrichten** |  | 5.72d | 2014-02-03 09:00 A | 2014-02-08 13:45 A |  | 100% |  | 2014-02-03 09:00 | 2014-02-08 13:45 | 5.72d |  | 2014-02-08 14:00 |  | 230.17h | 230.17h | 385 | 30 |
| 90 | 3.2.1 | Ophalen spullen |  | 3h | 2014-02-03 09:00 A | 2014-02-03 12:00 A |  | 100% |  | 2014-02-03 09:00 | 2014-02-03 12:00 | 3h | start no earlier than 2014-02-03 08:00 | 2014-02-07 17:00 | Corine Somers; Benodigheden kapper/visagist [0.1%]; Broodjes smeerders; Goodiebags [0.1%]; Eten/ drinken/bekers/borden [0.1%]; Kleding; Rode Loper; Versiering [0.1%] | 6h | 6h |  |  |
| 91 | 3.2.2 | Opbouwen |  | 2h | 2014-02-08 08:00 A | 2014-02-08 10:00 A |  | 100% |  | 2014-02-08 08:00 | 2014-02-08 10:00 | 2h | start no earlier than 2014-02-08 08:00 |  | Cédric Cortenraad; Corine Somers; Nicole van Ham; Roosmarijn Doedens | 8h | 8h |  |  |
| 92 | 3.2.3 | Klaarmaken lunch |  | 2h | 2014-02-08 08:00 A | 2014-02-08 10:00 A |  | 100% |  | 2014-02-08 08:00 | 2014-02-08 10:00 | 2h | start no earlier than 2014-02-08 08:00 |  | Broodjes smeerders [200%]; Eten/ drinken/bekers/borden [0.1%] | 4h | 4h | 30 |  |
| 93 | 3.2.4 | Aankomst verstandelijk beperkten en begeleiders | manual | 30min | 2014-02-08 10:00 A | 2014-02-08 10:30 A |  | 100% |  | 2014-02-08 10:00 | 2014-02-08 10:30 | 30min | must start on 2014-02-08 10:00 |  | Verstandelijk beperkten [2900%]; Vrijwilligers [2500%] | 27h | 27h |  |  |
| 94 | 3.2.5 | Omkleden 1 |  | 70min | 2014-02-08 10:30 A | 2014-02-08 11:40 A | 93 | 100% |  | 2014-02-08 10:30 | 2014-02-08 11:40 | 70min |  |  | Verstandelijk beperkten [2900%]; Vrijwilligers [2500%]; Kapper [800%]; visagist [800%]; Benodigheden kapper/visagist [0.1%] | 81.67h | 81.67h | 325 |  |
| 95 | 3.2.6 | Generale repetitie |  | 70min | 2014-02-08 11:40 A | 2014-02-08 12:50 A | 94 | 100% |  | 2014-02-08 11:40 | 2014-02-08 12:50 | 70min |  |  | Verstandelijk beperkten [2900%]; Vrijwilligers [2500%] | 63h | 63h |  |  |
| 96 | 3.2.7 | Pauze |  | 10min | 2014-02-08 12:50 A | 2014-02-08 13:00 A | 95 | 100% |  | 2014-02-08 12:50 | 2014-02-08 13:00 | 10min |  |  | Koffie [0.1%] |  |  | 30 | 30 |
| 97 | 3.2.8 | Lunch |  | 45min | 2014-02-08 13:00 A | 2014-02-08 13:45 A | 96 | 100% |  | 2014-02-08 13:00 | 2014-02-08 13:45 | 45min |  |  | Verstandelijk beperkten [2900%]; Vrijwilligers [2500%]; Eten/ drinken/bekers/borden [0.1%] | 40.5h | 40.5h |  |  |
| 98 | 3.3 | **Uitvoering modeshow** |  | 0.25d | 2014-02-08 14:00 A | 2014-02-08 16:00 A |  | 100% |  | 2014-02-08 14:00 | 2014-02-08 16:00 | 0.25d | start no earlier than 2014-02-08 14:00 |  | Verstandelijk beperkten [2900%]; Vrijwilligers [2500%]; Dansschool Vermeulen; Fotograaf; Presentator Joost Brauwer; Kleding; Rode Loper; Versiering [0.1%]; Muziek; Goodiebags [0.1%] | 129.92h | 129.92h | 200 | 200 |
| 99 | 3.3.1 | Openingswoord door organisatoren |  | 10min | 2014-02-08 14:00 A | 2014-02-08 14:10 A |  | 100% |  | 2014-02-08 14:00 | 2014-02-08 14:10 | 10min |  |  | Cédric Cortenraad; Corine Somers; Nicole van Ham; Roosmarijn Doedens | 0.67h | 0.67h |  |  |
| 100 | 3.3.2 | Start modeshow ronde 1 (groep 1 en 2) |  | 20min | 2014-02-08 14:10 A | 2014-02-08 14:30 A | 99 | 100% |  | 2014-02-08 14:10 | 2014-02-08 14:30 | 20min |  |  | Verstandelijk beperkten [1400%] | 4.67h | 4.67h |  |  |
| 101 | 3.3.3 | Act verzorgt door meneer Vermeulen |  | 20min | 2014-02-08 14:30 A | 2014-02-08 14:50 A | 100 | 100% |  | 2014-02-08 14:30 | 2014-02-08 14:50 | 20min |  |  | Vermeulen | 0.33h | 0.33h |  |  |
| 102 | 3.3.4 | Pauze |  | 10min | 2014-02-08 14:50 A | 2014-02-08 15:00 A | 101 | 100% |  | 2014-02-08 14:50 | 2014-02-08 15:00 | 10min |  |  |  |  |  |  |  |
| 103 | 3.3.5 | Modeshow ronde 2 (groep 3, 4 en 5) |  | 45min | 2014-02-08 15:00 A | 2014-02-08 15:45 A | 102 | 100% |  | 2014-02-08 15:00 | 2014-02-08 15:45 | 45min |  |  | Verstandelijk beperkten [1500%] | 11.25h | 11.25h |  |  |
| 104 | 3.3.6 | Buiging en afsluiting |  | 15min | 2014-02-08 15:45 A | 2014-02-08 16:00 A | 103 | 100% |  | 2014-02-08 15:45 | 2014-02-08 16:00 | 15min |  |  | Cédric Cortenraad; Corine Somers; Nicole van Ham; Roosmarijn Doedens | 1h | 1h |  |  |

| ID | WBS | Task | Duration | Start | Finish | Predecessors | Complete | Baseline start | Baseline finish | Baseline duration | Baseline 1 start | Baseline 1 finish | Constraint | Deadline | Resources | Work | Actual work |
| --- | --- | --- | --- | --- | --- | --- | --- | --- | --- | --- | --- | --- | --- | --- | --- | --- | --- |
| 105 | 3.4 | **Afsluiten** | 0.62d | 2014-02-08 16:00 A | 2014-02-10 12:00 A | 98 | 100% | 2014-02-08 16:00 | 2014-02-10 12:00 | 0.62d |  |  |  |  |  | 151h | 151h |
| 106 | 3.4.1 | Afbreken | 2h | 2014-02-08 16:00 A | 2014-02-08 18:00 A |  | 100% | 2014-02-08 16:00 | 2014-02-08 18:00 | 2h |  |  |  |  | Cédric Cortenraad; Corine Somers; Nicole van Ham; Roosmarijn Doedens | 8h | 8h |
| 107 | 3.4.2 | Omkleden 2 | 2h | 2014-02-08 16:00 A | 2014-02-08 18:00 A |  | 100% | 2014-02-08 16:00 | 2014-02-08 18:00 | 2h |  |  |  |  | Verstandelijk beperkten [2900%]; Vrijwilligers [2500%]; Kapper [800%]; visagist [800%] | 140h | 140h |
| 108 | 3.4.3 | Terugbrengen spullen | 3h | 2014-02-10 09:00 A | 2014-02-10 12:00 A |  | 100% | 2014-02-10 09:00 | 2014-02-10 12:00 | 3h |  |  | start no earlier than 2014-02-10 08:00 |  | Corine Somers | 3h | 3h |
| 109 | 4 | **Nazorgfase** | 13.62d | 2014-02-10 12:00 A | 2014-02-27 17:00 A | 51 | 100% | 2014-02-10 12:00 | 2014-02-10 13:00 | 0.12d | 2013-09-25 15:00 | 2013-09-25 16:00 |  |  |  | 34h | 34h |
| 110 | 4.1 | Eigen evaluatie | 1w | 2014-02-10 12:00 A | 2014-02-17 12:00 A |  | 100% |  |  |  |  |  |  |  | Cédric Cortenraad; Corine Somers; Nicole van Ham; Roosmarijn Doedens | 12h | 12h |
| 111 | 4.2 | Eindgesprek Rode Kruis | 1h | 2014-02-19 14:00 A | 2014-02-19 15:00 A |  | 100% |  |  |  |  |  | start no earlier than 2014-02-19 14:00 |  | Cédric Cortenraad; Corine Somers; Kimberly van der Laan; Nicole van Ham; Roosmarijn Doedens | 5h | 5h |
| 112 | 4.3 | Projectverslag | 2d | 2014-02-19 15:00 A | 2014-02-21 15:00 A | 111 | 100% | 2014-02-10 12:00 | 2014-02-10 13:00 | 1h | 2013-09-25 15:00 | 2013-09-25 16:00 |  | 2014-01-16 17:00 | Cédric Cortenraad; Corine Somers; Nicole van Ham; Roosmarijn Doedens | 12h | 12h |
| 113 | 4.4 | Eindgesprek Joyce | 1h | 2014-02-27 16:00 A | 2014-02-27 17:00 A |  | 100% |  |  |  |  |  | start no earlier than 2014-02-27 16:00 |  | Cédric Cortenraad; Corine Somers; Joyce Bruil; Nicole van Ham; Roosmarijn Doedens | 5h | 5h |
