# You are beautiful w6

Schedule from MS Project, 2013-09-10 to 2013-10-30, A marks actual dates.
Project CPM
Rode Kruis Studentendesk Nijmegen

## Calendars

- You are Beautiful: Mon-Tue off; Wed-Thu 15:00-17:00; Fri-Sun off. Exceptions (off unless hours are given): 2013-10-14 to 2013-10-18 (Herfstvakantie).
- 24 uur: Mon-Sun 00:00-24:00.

## Resources

| Resource | Group |
| --- | --- |
| Nicole van Ham | Student |
| Cédric Cortenraad | Student |
| Roosmarijn Doedens | Student |
| Corine Somers | Student |
| Joyce Bruil | Docent |
| Kimberly van der Laan | Opdrachtgever |

## Schedule

| ID | WBS | Task | Duration | Start | Finish | Predecessors | Complete | Remaining | Baseline start | Baseline finish | Baseline duration | Baseline 1 start | Baseline 1 finish | Total slack | Constraint | Deadline | Calendar | Resources | Work | Actual work |
| --- | --- | --- | --- | --- | --- | --- | --- | --- | --- | --- | --- | --- | --- | --- | --- | --- | --- | --- | --- | --- |
| 1 | 1 | **Voorbereidingsfase** | 1.03d | 2013-09-10 16:00 A | 2013-09-25 15:15 |  | 93% | 0.07d | 2013-09-10 16:00 | 2013-09-24 11:00 | 1d | 2013-09-10 16:00 | 2013-09-25 15:15 | 0d |  |  |  |  | 58h | 53h |
| 2 | 1.1 | Voorbereidend gesprek met opdrachtgever | 2h | 2013-09-10 16:00 A | 2013-09-10 18:00 A |  | 100% |  | 2013-09-10 16:00 | 2013-09-10 18:00 | 2h | 2013-09-10 16:00 | 2013-09-10 18:00 |  | must start on 2013-09-10 16:00 |  | 24 uur | Cédric Cortenraad; Corine Somers; Nicole van Ham; Roosmarijn Doedens; Kimberly van der Laan | 10h | 10h |
| 3 | 1.2 | Project bestand aanmaken | 2h | 2013-09-11 15:00 A | 2013-09-11 17:00 A | 2 | 100% |  | 2013-09-11 15:00 | 2013-09-11 17:00 | 2h | 2013-09-11 15:00 | 2013-09-11 17:00 |  |  |  |  | Cédric Cortenraad; Corine Somers; Nicole van Ham; Roosmarijn Doedens | 16h | 16h |
| 4 | 1.3 | **Opdracht 1 Resultaten beschrijven** | 0.34d | 2013-09-12 15:00 A | 2013-09-18 15:45 A | 3 | 100% |  | 2013-09-12 15:00 | 2013-09-18 15:45 | 0.34d | 2013-09-12 15:00 | 2013-09-18 15:45 |  |  |  |  |  | 11h | 11h |
| 5 | 1.3.1 | Voorbereiden projectresultaat | 1.75h | 2013-09-12 15:00 A | 2013-09-12 16:45 A |  | 100% |  | 2013-09-12 15:00 | 2013-09-12 16:45 | 1.75h | 2013-09-12 15:00 | 2013-09-12 16:45 |  |  |  |  | Cédric Cortenraad | 1.75h | 1.75h |
| 6 | 1.3.2 | Voorbereiden organisatieresultaat | 1.75h | 2013-09-12 15:00 A | 2013-09-12 16:45 A |  | 100% |  | 2013-09-12 15:00 | 2013-09-12 16:45 | 1.75h | 2013-09-12 15:00 | 2013-09-12 16:45 |  |  |  |  | Corine Somers | 1.75h | 1.75h |
| 7 | 1.3.3 | Voorbereiden omgevingsresultaat | 1.75h | 2013-09-12 15:00 A | 2013-09-12 16:45 A |  | 100% |  | 2013-09-12 15:00 | 2013-09-12 16:45 | 1.75h | 2013-09-12 15:00 | 2013-09-12 16:45 |  |  |  |  | Nicole van Ham | 1.75h | 1.75h |
| 8 | 1.3.4 | Voorbereiden bedrijfsresultaat | 1.75h | 2013-09-12 15:00 A | 2013-09-12 16:45 A |  | 100% |  | 2013-09-12 15:00 | 2013-09-12 16:45 | 1.75h | 2013-09-12 15:00 | 2013-09-12 16:45 |  |  |  |  | Roosmarijn Doedens | 1.75h | 1.75h |
| 9 | 1.3.5 | Bespreken projectresultaat | 0.25h | 2013-09-12 16:45 A | 2013-09-12 17:00 A | 5 | 100% |  | 2013-09-12 16:45 | 2013-09-12 17:00 | 0.25h | 2013-09-12 16:45 | 2013-09-12 17:00 |  |  |  |  | Cédric Cortenraad; Corine Somers; Nicole van Ham; Roosmarijn Doedens | 1h | 1h |
| 10 | 1.3.6 | Bespreken organisatieresultaat | 0.25h | 2013-09-18 15:00 A | 2013-09-18 15:15 A | 6, 9 | 100% |  | 2013-09-18 15:00 | 2013-09-18 15:15 | 0.25h | 2013-09-18 15:00 | 2013-09-18 15:15 |  |  |  |  | Cédric Cortenraad; Corine Somers; Nicole van Ham; Roosmarijn Doedens | 1h | 1h |
| 11 | 1.3.7 | Bespreken omgevingsresultaat | 0.25h | 2013-09-18 15:15 A | 2013-09-18 15:30 A | 7, 10 | 100% |  | 2013-09-18 15:15 | 2013-09-18 15:30 | 0.25h | 2013-09-18 15:15 | 2013-09-18 15:30 |  |  |  |  | Cédric Cortenraad; Corine Somers; Nicole van Ham; Roosmarijn Doedens | 1h | 1h |
| 12 | 1.3.8 | Bespreken bedrijfsresultaat | 0.25h | 2013-09-18 15:30 A | 2013-09-18 15:45 A | 8, 11 | 100% |  | 2013-09-18 15:30 | 2013-09-18 15:45 | 0.25h | 2013-09-18 15:30 | 2013-09-18 15:45 |  |  |  |  | Cédric Cortenraad; Corine Somers; Nicole van Ham; Roosmarijn Doedens | 1h | 1h |
| 13 | 1.4 | Opdracht 2 structurele inbedding | 0.5h | 2013-09-18 15:45 A | 2013-09-18 16:15 A | 4 | 100% |  | 2013-09-18 15:45 | 2013-09-18 16:15 | 0.5h | 2013-09-18 15:45 | 2013-09-18 16:15 |  |  |  |  | Cédric Cortenraad; Corine Somers; Nicole van Ham; Roosmarijn Doedens | 2h | 2h |
| 14 | 1.5 | **Opdracht 3** | 0d | 2013-09-18 16:15 A | 2013-09-18 16:16 A | 13 | 100% |  | 2013-09-18 16:15 | 2013-09-18 16:15 | 0d | 2013-09-18 16:15 | 2013-09-18 16:16 |  |  |  |  |  | 8h | 8h |
| 15 | 1.5.1 | Belanghebbende in kaart brengen | 0.02h | 2013-09-18 16:15 A | 2013-09-18 16:16 A |  | 100% |  | 2013-09-18 16:15 | 2013-09-18 16:15 | 0h | 2013-09-18 16:15 | 2013-09-18 16:16 |  |  |  |  | Cédric Cortenraad; Corine Somers | 3h | 3h |
| 16 | 1.5.2 | Belang en verantwoordelijkheid in kaart brengen | 0.02h | 2013-09-18 16:15 A | 2013-09-18 16:16 A |  | 100% |  | 2013-09-18 16:15 | 2013-09-18 16:15 | 0h | 2013-09-18 16:15 | 2013-09-18 16:16 |  |  |  |  | Nicole van Ham; Roosmarijn Doedens | 5h | 5h |
| 17 | 1.6 | **Opdracht 4** | 0.09d | 2013-09-18 16:16 A | 2013-09-19 15:00 A | 14 | 100% |  | 2013-09-18 16:15 | 2013-09-19 15:15 | 0.12d | 2013-09-18 16:16 | 2013-09-19 15:00 |  |  |  |  |  | 4h | 4h |
| 18 | 1.6.1 | krachtenveldanalyse | 0.73h | 2013-09-18 16:16 A | 2013-09-19 15:00 A |  | 100% |  | 2013-09-18 16:15 | 2013-09-19 15:15 | 1h | 2013-09-18 16:16 | 2013-09-19 15:00 |  |  |  |  | Cédric Cortenraad | 1h | 1h |
| 19 | 1.6.2 | relevantieanalyse | 0.73h | 2013-09-18 16:16 A | 2013-09-19 15:00 A |  | 100% |  | 2013-09-18 16:15 | 2013-09-19 15:15 | 1h | 2013-09-18 16:16 | 2013-09-19 15:00 |  |  |  |  | Corine Somers | 1h | 1h |
| 20 | 1.6.3 | houdingsanalyse | 0.73h | 2013-09-18 16:16 A | 2013-09-19 15:00 A |  | 100% |  | 2013-09-18 16:15 | 2013-09-19 15:15 | 1h | 2013-09-18 16:16 | 2013-09-19 15:00 |  |  |  |  | Nicole van Ham | 1h | 1h |
| 21 | 1.6.4 | Invloed analyses | 0.73h | 2013-09-18 16:16 A | 2013-09-19 15:00 A |  | 100% |  | 2013-09-18 16:15 | 2013-09-19 15:15 | 1h | 2013-09-18 16:16 | 2013-09-19 15:00 |  |  |  |  | Roosmarijn Doedens | 1h | 1h |
| 22 | 1.7 | **Samenvatting resultaten tot nu toe** | 0.16d | 2013-09-19 15:00 A | 2013-09-19 16:15 A |  | 100% |  | 2013-09-19 15:15 | 2013-09-19 16:30 | 0.16d | 2013-09-19 15:00 | 2013-09-19 16:15 |  |  |  |  |  | 2h | 2h |
| 23 | 1.7.1 | Schrijven samenvatting | 1h | 2013-09-19 15:00 A | 2013-09-19 16:00 A | 14 | 100% |  | 2013-09-19 15:15 | 2013-09-19 16:15 | 1h | 2013-09-19 15:00 | 2013-09-19 16:00 |  |  |  |  | Corine Somers | 1h | 1h |
| 24 | 1.7.2 | Kritisch bekijken samenvatting | 0.25h | 2013-09-19 16:00 A | 2013-09-19 16:15 A | 17, 23 | 100% |  | 2013-09-19 16:15 | 2013-09-19 16:30 | 0.25h | 2013-09-19 16:00 | 2013-09-19 16:15 |  |  |  |  | Cédric Cortenraad; Corine Somers; Nicole van Ham; Roosmarijn Doedens | 1h | 1h |
| 25 | 1.8 | Voortgangsgesprek met de opdrachtgever | 1h | 2013-09-24 10:00 | 2013-09-24 11:00 |  |  |  | 2013-09-24 10:00 | 2013-09-24 11:00 | 1h | 2013-09-24 10:00 | 2013-09-24 11:00 | 0d | must start on 2013-09-24 10:00 |  | 24 uur | Cédric Cortenraad; Corine Somers; Nicole van Ham; Roosmarijn Doedens; Kimberly van der Laan | 5h |  |
| 26 | 1.9 | aanvragen project | 0.25h | 2013-09-25 15:00 | 2013-09-25 15:15 | 25 |  |  | 2013-09-11 15:00 | 2013-09-11 16:00 | 1h | 2013-09-25 15:00 | 2013-09-25 15:15 | 0d |  | 2013-09-26 17:00 |  |  |  |  |

| ID | WBS | Task | Duration | Start | Finish | Predecessors | Complete | Remaining | Baseline start | Baseline finish | Baseline duration | Baseline 1 start | Baseline 1 finish | Total slack | Free slack | Constraint | Deadline | Resources | Work | Actual work |
| --- | --- | --- | --- | --- | --- | --- | --- | --- | --- | --- | --- | --- | --- | --- | --- | --- | --- | --- | --- | --- |
| 27 | 2 | **Definitiefase** | 2.22d | 2013-09-25 15:15 A | 2013-10-30 17:00 | 1 | 95% | 0.11d | 2013-09-25 15:00 | 2013-10-03 17:00 | 1d? | 2013-09-25 15:15 | 2013-10-10 17:00 | 0d |  |  |  |  | 63.25h | 63.25h |
| 28 | 2.1 | Planning definitiefase | 0.5h | 2013-09-25 15:15 A | 2013-09-25 15:45 A |  | 100% |  |  |  |  | 2013-09-25 15:15 | 2013-09-25 15:45 |  |  |  |  | Cédric Cortenraad; Corine Somers; Nicole van Ham; Roosmarijn Doedens | 0.5h | 0.5h |
| 29 | 2.2 | **Opdracht 5** | 0.31d | 2013-09-25 15:45 A | 2013-09-26 16:15 A | 28 | 100% |  |  |  |  | 2013-09-25 15:45 | 2013-09-26 16:15 |  |  |  |  |  | 9h | 9h |
| 30 | 2.2.1 | Alternatief 1 | 0.5h | 2013-09-25 15:45 A | 2013-09-25 16:15 A |  | 100% |  |  |  |  | 2013-09-25 15:45 | 2013-09-25 16:15 |  |  |  |  | Cédric Cortenraad; Corine Somers; Nicole van Ham; Roosmarijn Doedens | 2h | 2h |
| 31 | 2.2.2 | Alternatief 2 | 0.5h | 2013-09-25 16:15 A | 2013-09-25 16:45 A | 30 | 100% |  |  |  |  | 2013-09-25 16:15 | 2013-09-25 16:45 |  |  |  |  | Cédric Cortenraad; Corine Somers; Nicole van Ham; Roosmarijn Doedens | 2h | 2h |
| 32 | 2.2.3 | Alternatief 3 | 0.5h | 2013-09-25 16:45 A | 2013-09-26 15:15 A | 31 | 100% |  |  |  |  | 2013-09-25 16:45 | 2013-09-26 15:15 |  |  |  |  | Cédric Cortenraad; Corine Somers; Nicole van Ham; Roosmarijn Doedens | 2h | 2h |
| 33 | 2.2.4 | Uitwerking alternatief 1 | 1h | 2013-09-26 15:15 A | 2013-09-26 16:15 A | 32 | 100% |  |  |  |  | 2013-09-26 15:15 | 2013-09-26 16:15 |  |  |  |  | Cédric Cortenraad | 1h | 1h |
| 34 | 2.2.5 | Uitwerking alternatief 2 | 1h | 2013-09-26 15:15 A | 2013-09-26 16:15 A | 32 | 100% |  |  |  |  | 2013-09-26 15:15 | 2013-09-26 16:15 |  |  |  |  | Nicole van Ham | 1h | 1h |
| 35 | 2.2.6 | Uitwerking alternatief 3 | 1h | 2013-09-26 15:15 A | 2013-09-26 16:15 A | 32 | 100% |  |  |  |  | 2013-09-26 15:15 | 2013-09-26 16:15 |  |  |  |  | Roosmarijn Doedens | 1h | 1h |
| 36 | 2.3 | **Opdracht 6** | 0.09d | 2013-09-26 16:15 A | 2013-09-26 17:00 A | 29 | 100% |  |  |  |  | 2013-09-26 16:15 | 2013-09-26 17:00 |  |  |  |  |  | 0.75h | 0.75h |
| 37 | 2.3.1 | Projectplan stap 1 | 0.75h | 2013-09-26 16:15 A | 2013-09-26 17:00 A |  | 100% |  |  |  |  | 2013-09-26 16:15 | 2013-09-26 17:00 |  |  |  |  | Corine Somers | 0.75h | 0.75h |
| 38 | 2.4 | **Opdracht 7** | 1.12d | 2013-10-02 15:00 A | 2013-10-23 16:00 A | 36 | 100% |  |  |  |  | 2013-10-02 15:00 | 2013-10-03 17:00 |  |  | start no earlier than 2013-09-30 08:00 |  |  | 37h | 37h |
| 39 | 2.4.1 | WBS maken | 4h | 2013-10-02 15:00 A | 2013-10-03 17:00 A |  | 100% |  |  |  |  | 2013-10-02 15:00 | 2013-10-02 17:00 |  |  |  |  | Cédric Cortenraad; Corine Somers; Nicole van Ham; Roosmarijn Doedens | 16h | 16h |
| 40 | 2.4.2 | Producten project | 1h | 2013-10-09 16:00 A | 2013-10-09 17:00 A | 39, 42 | 100% |  |  |  |  | 2013-10-03 15:00 | 2013-10-03 15:30 |  |  |  |  | Cédric Cortenraad; Corine Somers; Nicole van Ham; Roosmarijn Doedens | 4h | 4h |
| 41 | 2.4.3 | PBS maken | 3h | 2013-10-10 15:00 A | 2013-10-23 16:00 A | 40 | 100% |  |  |  |  | 2013-10-03 15:30 | 2013-10-03 17:00 |  |  |  |  | Cédric Cortenraad; Corine Somers; Nicole van Ham; Roosmarijn Doedens | 12h | 12h |
| 42 | 2.4.4 | Afspraak 1 Joyce | 1h | 2013-10-09 15:00 A | 2013-10-09 16:00 A |  | 100% |  |  |  |  |  |  |  |  | must start on 2013-10-09 15:00 |  | Cédric Cortenraad; Corine Somers; Joyce Bruil; Nicole van Ham; Roosmarijn Doedens | 5h | 5h |
| 43 | 2.5 | **opdracht 8** | 0.5d | 2013-10-23 16:00 A | 2013-10-30 16:00 A | 38 | 100% |  |  |  |  | 2013-10-09 15:00 | 2013-10-10 17:00 |  |  |  |  |  | 16h | 16h |
| 44 | 2.5.1 | Inventarisatie risico's | 2h | 2013-10-23 16:00 A | 2013-10-24 16:00 A |  | 100% |  |  |  |  | 2013-10-09 15:00 | 2013-10-09 17:00 |  |  |  |  | Cédric Cortenraad; Corine Somers; Nicole van Ham; Roosmarijn Doedens | 8h | 8h |
| 45 | 2.5.2 | Inschatting risico's | 1h | 2013-10-24 16:00 A | 2013-10-24 17:00 A | 44 | 100% |  |  |  |  | 2013-10-10 15:00 | 2013-10-10 16:00 |  |  |  |  | Cédric Cortenraad; Corine Somers; Nicole van Ham; Roosmarijn Doedens | 4h | 4h |
| 46 | 2.5.3 | Tegen maatregelen bedenken | 1h | 2013-10-30 15:00 A | 2013-10-30 16:00 A | 45 | 100% |  |  |  |  | 2013-10-10 16:00 | 2013-10-10 17:00 |  |  |  |  | Cédric Cortenraad; Corine Somers; Nicole van Ham; Roosmarijn Doedens | 4h | 4h |
| 47 | 2.6 | Projectplan | 1h | 2013-10-30 16:00 | 2013-10-30 17:00 | 43 |  |  | 2013-10-09 15:00 | 2013-10-09 16:00 | 1h | 2013-09-25 15:15 | 2013-09-25 16:15 | 0d |  |  | 2013-10-31 17:00 |  |  |  |
| 48 | 3 | Uitvoeringsfase | 1d? | 2013-09-11 15:00 | 2013-09-19 17:00 |  |  |  | 2013-10-30 16:00 | 2013-11-13 16:00 | 1d? | 2013-09-11 15:00 | 2013-09-19 17:00 | 2.12d | 0d |  |  |  |  |  |
| 49 | 4 | **Nazorgfase** | 0.12d | 2013-09-25 15:00 | 2013-09-25 16:00 | 48 |  |  | 2013-11-13 16:00 | 2013-11-13 17:00 | 0.12d | 2013-09-25 15:00 | 2013-09-25 16:00 | 2.12d |  |  |  |  |  |  |
| 50 | 4.1 | Projectverslag | 1h | 2013-09-25 15:00 | 2013-09-25 16:00 |  |  |  | 2013-11-13 16:00 | 2013-11-13 17:00 | 1h | 2013-09-25 15:00 | 2013-09-25 16:00 | 2.12d |  |  | 2014-01-16 17:00 |  |  |  |
